# Target Hall Scheduled Activities,Apr 07-June 26 2015

Schedule from MS Project, 2015-04-07 to 2015-06-26, A marks actual dates.

## Calendars

- Standard: Mon-Fri 08:00-12:00, 13:00-17:00; Sat-Sun off.

## Resources

| Resource |
| --- |
| D.Wang |
| T.Cave |
| A.Mjos |
| C.Fisher |
| D.McDonald |
| RPG |
| ISAC Opps |
| M.Dalla Valle |
| K.Ng |
| G.Minor |
| D.Jackson |
| I.Earle |

## Schedule

| ID | WBS | Task | Duration | Start | Finish | Predecessors | Complete | Total slack | Free slack | Constraint | Resources | Work |
| --- | --- | --- | --- | --- | --- | --- | --- | --- | --- | --- | --- | --- |
| 1 | 1 | **TM4 Ta#45 ready for Beam at ITE** | 4d | 2015-04-07 08:00 A | 2015-04-10 17:00 A |  | 100% |  |  |  |  |  |
| 2 | 1.1 | Grounding Test-ITW, ITE | 1d | 2015-04-07 08:00 A | 2015-04-07 17:00 A |  | 100% |  |  |  |  |  |
| 3 | 1.2 | Foot Anchors Grout-ITW, ITE Handrails | 2.5d | 2015-04-08 08:00 A | 2015-04-10 12:00 A | 2 | 100% |  |  |  |  |  |
| 4 | 1.3 | Shielding Blocks Move-ITW to ITE | 0.5d | 2015-04-10 13:00 A | 2015-04-10 17:00 A | 3 | 100% |  |  |  |  |  |
| 5 | 2 | **TM1-TM2-TM4 Target Hall Activities** | 55d | 2015-04-13 08:00 | 2015-06-26 17:00 |  |  | 0d |  |  |  | 773.6h |
| 6 | 2.1 | **TM1 UCx Ready for Beam at ITW** | 9d | 2015-04-16 08:00 | 2015-04-28 17:00 |  |  | 42d |  |  |  | 93.6h |
| 7 | 2.1.1 | New Ucx Target in SHC/Cameras set up | 0.2d | 2015-04-16 08:00 | 2015-04-16 09:36 |  |  | 42d | 0d | start no earlier than 2015-04-16 08:00 | A.Mjos; I.Earle; T.Cave | 4.8h |
| 8 | 2.1.2 | Moduel Move-TM1-Silo to SHC | 0.2d | 2015-04-16 09:36 | 2015-04-16 11:12 | 7 |  | 42d | 0d | start no earlier than 2015-04-16 08:00 | T.Cave; D.Wang | 3.2h |
| 9 | 2.1.3 | Ucx target install /Leak , Electrical Check at SHC | 0.2d | 2015-04-16 11:12 | 2015-04-16 13:48 | 8 |  | 42d | 0d | start no earlier than 2015-04-16 08:00 | I.Earle; T.Cave; D.Wang | 4.8h |
| 10 | 2.1.4 | Module Move- TM1 -SHC to CS | 0.2d | 2015-04-16 13:48 | 2015-04-16 15:24 | 9 |  | 42d | 0d | start no earlier than 2015-04-16 08:00 | D.Wang; T.Cave | 3.2h |
| 11 | 2.1.5 | TM1 Vacuum Connect at CS/ CS Pump Down | 0.2d | 2015-04-16 15:24 | 2015-04-16 17:00 | 10 |  | 42d | 0d | start no earlier than 2015-04-16 08:00 | D.Wang | 1.6h |
| 12 | 2.1.6 | Heium Pressure Test-TM1 HS line at CS | 0.5d | 2015-04-17 08:00 | 2015-04-17 12:00 | 11 |  | 42d | 0d |  | D.Wang | 4h |
| 13 | 2.1.7 | TM1 Heaters, Water Connect at CS/HV Cover Installed | 0.5d | 2015-04-17 13:00 | 2015-04-17 17:00 | 12 |  | 42d | 0d | start no earlier than 2015-04-17 08:00 | D.Wang; D.McDonald | 8h |
| 14 | 2.1.8 | Module Conditioning-TM1 at CS | 5.5d | 2015-04-20 08:00 | 2015-04-27 12:00 | 13 |  | 42d | 0d | start no earlier than 2015-04-20 08:00 | A.Mjos | 44h |
| 15 | 2.1.9 | Finish of Conditioning/Module Disconnect -TM1 at CS | 0.5d | 2015-04-27 13:00 | 2015-04-27 17:00 | 14 |  | 42d | 0d |  | D.Wang | 4h |
| 16 | 2.1.10 | Argon Vent CS /ITW cameras Set up/Shield Plug Move from ITW | 0.25d | 2015-04-28 08:00 | 2015-04-28 10:00 | 15 |  | 42d | 0d |  | D.Wang; T.Cave | 4h |
| 17 | 2.1.11 | Module Move -TM1-CS to ITW | 0.25d | 2015-04-28 10:00 | 2015-04-28 12:00 | 16 |  | 42d | 0d |  | D.Wang; T.Cave | 4h |
| 18 | 2.1.12 | Module Connect-TM1 at ITW/Start of Turbopumps | 0.5d | 2015-04-28 13:00 | 2015-04-28 17:00 | 17 |  | 42d | 17d |  | D.Wang; D.McDonald | 8h |
| 19 | 2.2 | **TM2 Refurbishment Completion** | 55d | 2015-04-13 08:00 | 2015-06-26 17:00 |  |  | 0d |  |  |  | 548h |
| 20 | 2.2.1 | TM2 Top Service Cap Reconfiguration | 3d | 2015-04-13 08:00 | 2015-04-15 17:00 |  |  | 50d | 16d | finish no earlier than 2015-04-15 17:00 | D.Wang | 24h |
| 21 | 2.2.2 | Module Move -TM2-Silo to ITW | 1d | 2015-04-30 08:00 | 2015-04-30 17:00 |  |  | 9d | 0d | start no earlier than 2015-04-30 08:00 | T.Cave; D.Wang | 16h |
| 22 | 2.2.3 | TM2 Wiring Prepare/Work Area Set up in TH | 1d | 2015-05-01 08:00 | 2015-05-01 17:00 | 21 |  | 9d | 0d |  | D.Wang; T.Cave | 16h |
| 23 | 2.2.4 | TM2 Wiring - SHC & TM2 Service Cap | 2d | 2015-05-04 08:00 | 2015-05-05 17:00 | 22 |  | 9d | 0d |  | T.Cave; C.Fisher; D.Wang | 48h |
| 24 | 2.2.5 | Module Move-TM2-SHC to CS | 1d | 2015-05-06 08:00 | 2015-05-06 17:00 | 23 |  | 9d | 0d |  | T.Cave; D.Wang | 16h |
| 25 | 2.2.6 | Source Tray Install on Transfer Table/Transfer Source Tray into SHC | 1d | 2015-05-07 08:00 | 2015-05-07 17:00 | 24 |  | 9d | 0d |  | D.Wang; C.Fisher; T.Cave | 24h |
| 26 | 2.2.7 | TM2 Wiring- CS & Service Cap | 2d | 2015-05-08 08:00 | 2015-05-11 17:00 | 25, 20 |  | 34d |  |  | T.Cave; D.Jackson; D.Wang | 48h |
| 27 | 2.2.8 | Remove Transfer table-SHC to TH/Clean up | 1d | 2015-05-12 08:00 | 2015-05-12 17:00 | 25 |  | 7d | 0d | start no earlier than 2015-05-12 08:00 | C.Fisher; T.Cave; D.Wang | 24h |
| 28 | 2.2.9 | TM2 Wiring-CS & Service Cap | 1d | 2015-05-13 08:00 | 2015-05-13 17:00 | 27 |  | 7d | 0d |  | T.Cave; D.Jackson; D.Wang | 24h |
| 29 | 2.2.10 | Module Move- TM2 -CS to SHC | 1d | 2015-05-14 08:00 | 2015-05-14 17:00 | 28 |  | 7d | 6d |  | T.Cave; D.Wang | 16h |
| 30 | 2.2.11 | Leak, Electrical Check-TM2 at SHC | 1d | 2015-05-25 08:00 | 2015-05-25 17:00 | 29 |  | 1d | 0d | start no earlier than 2015-05-25 08:00 | C.Fisher; T.Cave; D.Wang; D.Jackson | 32h |
| 31 | 2.2.12 | Module Move-TM2-SHC to CS/ Start of CS Pumps | 1d | 2015-05-26 08:00 | 2015-05-26 17:00 | 30 |  | 1d | 0d | start no earlier than 2015-05-26 08:00 | T.Cave; D.Wang | 16h |
| 32 | 2.2.13 | Helium Pressure Test on TM2 Water Lines at CS | 2d | 2015-05-27 08:00 | 2015-05-28 17:00 | 31 |  | 1d | 0d |  | D.Wang | 16h |
| 33 | 2.2.14 | Module Move -TM2-CS to Silo | 1d | 2015-05-29 08:00 | 2015-05-29 17:00 | 32 |  | 1d | 0d |  | D.Wang; T.Cave | 16h |
| 34 | 2.2.15 | TM2 Dummy Target Insert-SHC | 0.5d | 2015-06-11 08:00 | 2015-06-11 12:00 | 33, 51 |  | 1d | 0d | start no earlier than 2015-06-11 08:00 | C.Fisher; A.Mjos | 8h |
| 35 | 2.2.16 | Module Move-TM2-Silo to SHC | 0.5d | 2015-06-11 13:00 | 2015-06-11 17:00 | 34 |  | 1d | 0d |  | T.Cave; D.Wang | 8h |
| 36 | 2.2.17 | Dummy Target Install/Leak, Electrical Check | 0.5d | 2015-06-12 08:00 | 2015-06-12 12:00 | 35 |  | 1d | 0d | start no earlier than 2015-06-12 08:00 | C.Fisher; T.Cave; D.Wang | 12h |
| 37 | 2.2.18 | Module Move- TM2 -SHC to CS/Start of CS Pumps | 0.5d | 2015-06-12 13:00 | 2015-06-12 17:00 | 36 |  | 1d |  | start no earlier than 2015-06-12 08:00 | D.Wang; T.Cave | 8h |
| 38 | 2.2.19 | Helium Pressure Test -TM2 HS Line at CS/TM2 Connnect at CS | 1d | 2015-06-16 08:00 | 2015-06-16 17:00 | 37 |  | 0d |  | start no earlier than 2015-06-16 08:00 | D.Wang | 8h |
| 39 | 2.2.20 | TM2 Test at CS | 7d | 2015-06-17 08:00 | 2015-06-25 17:00 | 38 |  | 0d |  | start no earlier than 2015-06-17 08:00 | A.Mjos; G.Minor; D.Jackson | 168h |
| 40 | 2.2.21 | TM2 Fully Operational/Complete TM2 Refurbishment | 1d | 2015-06-26 08:00 | 2015-06-26 17:00 | 39 |  | 0d |  | start no earlier than 2015-06-26 08:00 |  |  |

| ID | WBS | Task | Duration | Start | Finish | Predecessors | Total slack | Free slack | Constraint | Resources | Work |
| --- | --- | --- | --- | --- | --- | --- | --- | --- | --- | --- | --- |
| 41 | 2.3 | **TM4 HpSiC Ready for Beam at ITE** | 21d | 2015-05-22 08:00 | 2015-06-19 17:00 |  | 5d |  |  |  | 132h |
| 42 | 2.3.1 | Shielding Blocks Move-ITE to ITW | 1d | 2015-05-22 08:00 | 2015-05-22 17:00 | 18 | 25d |  | start no earlier than 2015-05-22 08:00 | D.Wang; D.McDonald | 16h |
| 43 | 2.3.2 | New HP SiC Target in SHC | 1d | 2015-06-01 08:00 | 2015-06-01 17:00 | 33 | 1d | 0d | start no earlier than 2015-06-01 08:00 | C.Fisher; A.Mjos | 16h |
| 44 | 2.3.3 | Cameras set up/Module Move-TM4 -ITE to SHC | 0.5d | 2015-06-02 08:00 | 2015-06-02 12:00 | 43 | 1d | 0d | start no earlier than 2015-06-02 08:00 | T.Cave; D.Wang | 8h |
| 45 | 2.3.4 | New SiC Target Install/Electrical,vacuum Check | 0.5d | 2015-06-02 13:00 | 2015-06-02 17:00 | 44 | 1d | 0d |  | C.Fisher; D.Wang; T.Cave | 12h |
| 46 | 2.3.5 | Module Move-TM4-SHC to CS/Start of CS Turbo Pumps | 1d | 2015-06-03 08:00 | 2015-06-03 17:00 | 45 | 1d | 0d |  | D.Wang; T.Cave | 16h |
| 47 | 2.3.6 | Helium Pressure Test/Connect TM4 At CS/HV Cover on | 0.5d | 2015-06-04 08:00 | 2015-06-04 12:00 | 46 | 1d | 0d |  | D.Wang | 4h |
| 48 | 2.3.7 | Module Conditioning-TM4 at CS | 3d | 2015-06-04 13:00 | 2015-06-09 12:00 | 47 | 1d | 0d |  | A.Mjos | 24h |
| 49 | 2.3.8 | Finish of Conditioning/Module Disconnect -TM4 at CS | 0.5d | 2015-06-09 13:00 | 2015-06-09 17:00 | 48 | 1d | 0d |  | D.Wang | 4h |
| 50 | 2.3.9 | Module Move -TM4-CS to ITE | 0.5d | 2015-06-10 08:00 | 2015-06-10 12:00 | 49 | 1d | 0d | start no earlier than 2015-06-10 08:00 | T.Cave; D.Wang | 8h |
| 51 | 2.3.10 | Module Connect-TM4 at ITW/Start of ITE Turbopumps | 0.5d | 2015-06-10 13:00 | 2015-06-10 17:00 | 50 | 1d | 0d | start no earlier than 2015-06-10 08:00 | D.Wang; D.McDonald | 8h |
| 52 | 2.3.11 | Shielding Blocks Move-ITW to ITE/ ITE Ready for Proton Beam | 1d | 2015-06-19 08:00 | 2015-06-19 17:00 | 51 | 5d |  | start no earlier than 2015-06-19 08:00 | D.Wang; D.McDonald | 16h |
